# Programación - Remodelación Apto Studio 603

Schedule from MS Project, 2025-10-01 to 2026-03-17.

## Calendars

- Estándar: Mon-Fri 09:00-13:00, 15:00-19:00; Sat-Sun off.

## Schedule

| ID | WBS | Task | Type | Duration | Start | Finish | Predecessors | Total slack | Constraint |
| --- | --- | --- | --- | --- | --- | --- | --- | --- | --- |
| 1 | 1 | **PUEBLOS DORADOS - APULO** |  | 120d | 2025-10-01 | 2026-03-17 |  | 0d |  |
| 2 | 1.1 | Inicio de proyecto | milestone | 0d | 2025-10-01 | 2025-10-01 |  | 0d | start no earlier than 2025-10-01 |
| 3 | 1.2 | PRELIMINARES |  | 4d | 2025-10-01 | 2025-10-06 | 2 | 0d |  |
| 4 | 1.3 | EXCAVACIONES Y RELLENOS |  | 20d | 2025-10-07 | 2025-11-03 | 3 | 0d |  |
| 5 | 1.4 | INSTALACIONES ELÉCTRICAS |  | 4d | 2026-01-27 | 2026-01-30 | 8SS | 32d |  |
| 6 | 1.5 | INSTALACIONES HIDROSANITARIAS |  | 4d | 2026-01-27 | 2026-01-30 | 4, 7 | 32d |  |
| 7 | 1.6 | PAVIMENTOS |  | 60d | 2025-11-04 | 2026-01-26 | 4 | 0d |  |
| 8 | 1.7 | MOBILIARIO URBANO |  | 30d | 2026-01-27 | 2026-03-09 | 7 | 0d |  |
| 9 | 1.8 | PAISAJISMO |  | 14d | 2026-02-17 | 2026-03-06 | 8SS+5% | 0d |  |
| 10 | 1.9 | RECONSTITUCIÓN DE FACHADAS Y ARTE URBANO |  | 14d | 2026-02-26 | 2026-03-17 | 9SS+5% | 0d |  |
| 11 | 1.10 | Fin de proyecto | milestone | 0d | 2026-03-17 | 2026-03-17 | 10, 5 | 0d |  |
